# 205b91

Schedule from MS Project, 2005-09-22 to 2006-02-15, status date 2002-12-06.
VEGRAD d.d.

## Calendars

- Standard: Mon-Sat 08:00-12:00, 13:00-17:00; Sun off. Exceptions (off unless hours are given): 2005-10-31 to 2005-11-01, 2005-12-24 to 2005-12-25, 2006-01-02 to 2006-01-07.

## Schedule

| ID | WBS | Task | Duration | Start | Finish | Predecessors | Total slack | Free slack | Constraint |
| --- | --- | --- | --- | --- | --- | --- | --- | --- | --- |
| 1 | 1 | PRILOGA C: POGODBENI TERMINSKI PLAN | 1d? | 2005-09-26 | 2005-09-26 |  | 113d |  |  |
| 2 | 2 | **DVA VEČSTANOVANJSKA OBJEKTA V LJUBLJANI** | 117d | 2005-09-22 | 2006-02-15 |  | 0d |  |  |
| 3 | 2.1 | **OBJEKT 1** | 113d | 2005-09-22 | 2006-02-10 |  | 4d |  |  |
| 4 | 2.1.1 | **PRIPRAVLJALNA DELA** | 10d | 2005-09-22 | 2005-10-03 |  | 107d |  |  |
| 5 | 2.1.1.1 | Priprava gradbišča, postavitev ograj, kontej.skladišč, strojev, ured. dovoza | 7d | 2005-09-22 | 2005-09-29 |  | 218d | 0d | start no earlier than 2005-09-22 |
| 6 | 2.1.1.2 | Odriv humusa, široki izkop,odvoz na deponijo,planiranje dna gradbene jame | 7d | 2005-09-26 | 2005-10-03 | 5SS+3d | 218d |  | finish no earlier than 2005-05-19 |
| 7 | 2.1.2 | **TEMELJI** | 15d | 2005-10-03 | 2005-10-19 |  | 93d |  |  |
| 8 | 2.1.2.1 | Izkop za temelje | 3d | 2005-10-03 | 2005-10-05 |  | 212d | 0d | start no earlier than 2005-10-02 |
| 9 | 2.1.2.2 | Podložni beton pod temelji | 6d | 2005-10-04 | 2005-10-10 | 8SS+1d | 212d | 0d | finish no earlier than 2004-12-08 |
| 10 | 2.1.2.3 | Izdelava temeljev točkovnih in pasovnih, zasip za temelji | 12d | 2005-10-05 | 2005-10-18 | 9SS+1d | 202d | 0d | start no earlier than 2005-01-17 |
| 11 | 2.1.2.4 | vgrajevanje tampona z utrjevanjem | 10d | 2005-10-08 | 2005-10-19 | 10SS+3d | 203d | 0d | start no earlier than 2005-05-16 |
| 12 | 2.1.3 | KANALIZACIJA notranja, kinete, zasip | 10d | 2005-10-10 | 2005-10-20 | 11SS+1d | 203d |  |  |
| 13 | 2.1.4 | TALNA PLOŠČA | 10d | 2005-10-11 | 2005-10-21 | 10SS+5d | 202d |  | start no earlier than 2005-03-14 |
| 14 | 2.1.5 | **PRITLIČJE** | 14d | 2005-10-17 | 2005-11-03 |  | 66d |  |  |
| 15 | 2.1.5.1 | ab stene, stebri, vertikalne vezi | 9d | 2005-10-17 | 2005-10-26 |  | 134d | 0d | start no earlier than 2005-10-17 |
| 16 | 2.1.5.2 | zidanje zidov | 9d | 2005-10-17 | 2005-10-26 | 15SS | 198d |  | start no earlier than 2005-06-18 |
| 17 | 2.1.5.3 | horizontalne vezi, preklade, pošča | 8d | 2005-10-24 | 2005-11-03 | 15FS-3d | 134d | 0d | start no earlier than 2005-06-29 |
| 18 | 2.1.6 | **1. ETAŽA** | 15d | 2005-10-29 | 2005-11-17 |  | 66d |  |  |
| 19 | 2.1.6.1 | ab stene, stebri, vertikalne vezi | 9d | 2005-10-29 | 2005-11-10 | 17FS-3d | 134d | 0d |  |
| 20 | 2.1.6.2 | zidanje zidov | 9d | 2005-10-29 | 2005-11-10 | 19SS | 187d |  | start no earlier than 2005-06-18 |
| 21 | 2.1.6.3 | horizontalne vezi, preklade, pošča | 8d | 2005-11-09 | 2005-11-17 | 19FS-2d | 134d | 0d |  |
| 22 | 2.1.7 | VENEC NA STREHI | 6d | 2005-11-16 | 2005-11-22 | 21FS-2d | 134d | 0d |  |
| 23 | 2.1.8 | Predelne stene | 36d | 2005-12-23 | 2006-02-10 |  | 115d |  | start no earlier than 2005-12-23 |
| 24 | 2.2 | **OBJEKT 2** | 105d | 2005-10-06 | 2006-02-15 |  | 0d |  |  |
| 25 | 2.2.1 | **TEMELJI** | 15d | 2005-10-06 | 2005-10-22 |  | 15d |  |  |
| 26 | 2.2.1.1 | Izkop za temelje | 3d | 2005-10-06 | 2005-10-08 |  | 98d | 0d | start no earlier than 2005-10-06 |
| 27 | 2.2.1.2 | Podložni beton pod temelji | 6d | 2005-10-07 | 2005-10-13 | 26FS-2d | 98d | 0d | finish no earlier than 2004-12-08 |
| 28 | 2.2.1.3 | Izdelava temeljev točkovnih in pasovnih, zasip za temelji | 12d | 2005-10-08 | 2005-10-21 | 27SS+1d | 13d | 0d | start no earlier than 2005-01-17 |
| 29 | 2.2.1.4 | vgrajevanje tampona z utrjevanjem | 10d | 2005-10-12 | 2005-10-22 | 28SS+3d | 89d | 0d | start no earlier than 2005-05-16 |
| 30 | 2.2.2 | KANALIZACIJA notranja, kinete, zasip | 10d | 2005-10-13 | 2005-10-24 | 29SS+1d | 89d |  |  |
| 31 | 2.2.3 | TALNA PLOŠČA | 10d | 2005-10-14 | 2005-10-25 | 28SS+5d | 13d | 0d | start no earlier than 2005-03-14 |

| ID | WBS | Task | Duration | Start | Finish | Predecessors | Total slack | Free slack | Constraint |
| --- | --- | --- | --- | --- | --- | --- | --- | --- | --- |
| 32 | 2.2.4 | **PRITLIČJE** | 15d | 2005-10-26 | 2005-11-14 |  | 13d |  |  |
| 33 | 2.2.4.1 | ab stene, stebri, vertikalne vezi | 10d | 2005-10-26 | 2005-11-08 | 31 | 13d | 0d | start no earlier than 2005-10-17 |
| 34 | 2.2.4.2 | zidanje zidov | 9d | 2005-10-26 | 2005-11-07 | 33SS | 79d |  | start no earlier than 2005-06-18 |
| 35 | 2.2.4.3 | horizontalne vezi, preklade, pošča | 8d | 2005-11-05 | 2005-11-14 | 33FS-3d | 13d | 0d | start no earlier than 2005-06-29 |
| 36 | 2.2.5 | **1. ETAŽA** | 59d | 2005-11-11 | 2006-01-26 |  | 13d |  |  |
| 37 | 2.2.5.1 | ab stene, stebri, vertikalne vezi | 9d | 2005-11-11 | 2005-11-21 | 35FS-3d | 13d | 0d |  |
| 38 | 2.2.5.2 | zidanje zidov | 9d | 2005-11-11 | 2005-11-21 | 37SS | 67d |  | start no earlier than 2005-06-18 |
| 39 | 2.2.5.3 | horizontalne vezi, preklade, pošča | 8d | 2005-11-19 | 2006-01-26 | 37FS-2d | 13d | 0d |  |
| 40 | 2.2.6 | VENEC NA STREHI | 6d | 2006-01-31 | 2006-02-06 | 39FS-2d | 8d |  | start no earlier than 2006-01-31 |
| 41 | 2.2.7 | Predelne stene | 27d | 2006-01-16 | 2006-02-15 |  | 0d |  | start no earlier than 2006-01-16 |
