# 205b91

Schedule from MS Project, 2005-09-22 to 2006-02-22, status date 2002-12-06, A marks actual dates.
VEGRAD d.d.

## Calendars

- Standard: Mon-Sat 08:00-12:00, 13:00-17:00; Sun off. Exceptions (off unless hours are given): 2005-09-24, 2005-10-01, 2005-10-29, 2005-10-31 to 2005-11-01, 2005-11-02 08:00-12:00, 13:00-17:00, 2005-11-13 08:00-12:00, 13:00-17:00, 2005-12-24 to 2005-12-31, 2006-01-02, 2006-01-03 to 2006-01-07 08:00-12:00, 13:00-17:00.

## Schedule

| ID | WBS | Task | Type | Duration | Start | Finish | Predecessors | Complete | Baseline start | Baseline finish | Baseline duration | Total slack | Constraint |
| --- | --- | --- | --- | --- | --- | --- | --- | --- | --- | --- | --- | --- | --- |
| 1 | 1 | PRILOGA D: PRIMERJAVA PLANIRANEGA IN DEJANSKO IZVEDENEGA DELA |  | 1d? | 2005-09-26 | 2005-09-26 |  |  |  |  |  | 117d |  |
| 2 | 2 | **DVA VEČSTANOVANJSKA OBJEKTA V LJUBLJANI** |  | 119.25d | 2005-09-22 A | 2006-02-22 A |  | 100% | 2005-09-22 | 2006-02-15 | 117d |  |  |
| 3 | 2.1 | **OBJEKT 1** |  | 103.25d | 2005-09-22 A | 2006-02-03 A |  | 100% | 2005-09-22 | 2006-02-10 | 113d |  |  |
| 4 | 2.1.1 | **PRIPRAVLJALNA DELA** |  | 9d | 2005-09-22 A | 2005-10-05 A |  | 100% | 2005-09-22 | 2005-10-03 | 10d |  |  |
| 5 | 2.1.1.1 | Priprava gradbišča, postavitev ograj, kontej.skladišč, strojev, ured. Dovoza |  | 9d | 2005-09-22 A | 2005-10-05 A |  | 100% | 2005-09-22 | 2005-09-29 | 7d |  | finish no earlier than 2005-10-04 |
| 6 | 2.1.1.2 | Odriv humusa, široki izkop,odvoz na deponijo,planiranje dna gradbene jame | milestone | 0d | 2005-10-05 A | 2005-10-05 A | 5SS+3d | 100% | 2005-09-26 | 2005-10-03 | 7d |  | start no earlier than 2005-10-04 |
| 7 | 2.1.2 | **TEMELJI** |  | 12d | 2005-10-06 A | 2005-10-19 A |  | 100% | 2005-10-03 | 2005-10-19 | 15d |  |  |
| 8 | 2.1.2.1 | Izkop za temelje |  | 1d | 2005-10-06 A | 2005-10-06 A |  | 100% | 2005-10-03 | 2005-10-05 | 3d |  | start no earlier than 2005-10-06 |
| 9 | 2.1.2.2 | Podložni beton pod temelji in talno ploščo |  | 7d | 2005-10-07 A | 2005-10-14 A | 8SS+1d | 100% | 2005-10-04 | 2005-10-10 | 6d |  | finish no earlier than 2004-12-08 |
| 10 | 2.1.2.3 | Izdelava temeljev točkovnih in pasovnih, zasip za temelji |  | 7d | 2005-10-12 A | 2005-10-19 A | 9SS+1d | 100% | 2005-10-05 | 2005-10-18 | 12d |  | start no earlier than 2005-10-12 |
| 11 | 2.1.2.4 | vgrajevanje tampona z utrjevanjem |  | 1d | 2005-10-06 A | 2005-10-06 A | 10SS+3d | 100% | 2005-10-08 | 2005-10-19 | 10d |  | start no earlier than 2005-05-16 |
| 12 | 2.1.3 | KANALIZACIJA notranja, kinete, zasip |  | 5d | 2005-10-10 A | 2005-10-14 A | 11SS+1d | 100% | 2005-10-10 | 2005-10-20 | 10d |  | start no earlier than 2005-10-10 |
| 13 | 2.1.4 | TALNA PLOŠČA |  | 4d | 2005-10-15 A | 2005-10-19 A | 10SS+5d | 100% | 2005-10-11 | 2005-10-21 | 10d |  | start no earlier than 2005-10-08 |
| 14 | 2.1.5 | **PRITLIČJE** |  | 23d | 2005-10-22 A | 2005-11-19 A |  | 100% | 2005-10-17 | 2005-11-03 | 14d |  |  |
| 15 | 2.1.5.1 | ab stene, stebri, vertikalne vezi |  | 17d | 2005-10-27 A | 2005-11-17 A |  | 100% | 2005-10-17 | 2005-10-26 | 9d |  | start no earlier than 2005-10-27 |
| 16 | 2.1.5.2 | zidanje zidov |  | 16d | 2005-10-22 A | 2005-11-12 A | 15SS | 100% | 2005-10-17 | 2005-10-26 | 9d |  | start no earlier than 2005-10-22 |
| 17 | 2.1.5.3 | horizontalne vezi, preklade, pošča |  | 13d | 2005-11-07 A | 2005-11-19 A | 15FS-3d | 100% | 2005-10-24 | 2005-11-03 | 8d |  | start no earlier than 2005-11-07 |
| 18 | 2.1.6 | **1. ETAŽA** |  | 17d | 2005-11-17 A | 2005-12-06 A |  | 100% | 2005-10-29 | 2005-11-17 | 15d |  |  |
| 19 | 2.1.6.1 | ab stene, stebri, vertikalne vezi |  | 11d | 2005-11-21 A | 2005-12-02 A | 17FS-3d | 100% | 2005-10-29 | 2005-11-10 | 9d |  | start no earlier than 2005-11-19 |
| 20 | 2.1.6.2 | zidanje zidov |  | 12d | 2005-11-17 A | 2005-11-30 A | 19SS | 100% | 2005-10-29 | 2005-11-10 | 9d |  | start no earlier than 2005-11-17 |
| 21 | 2.1.6.3 | horizontalne vezi, preklade, pošča |  | 11d | 2005-11-24 A | 2005-12-06 A | 19FS-2d | 100% | 2005-11-09 | 2005-11-17 | 8d |  | start no earlier than 2005-11-23 |
| 22 | 2.1.7 | VENEC NA STREHI |  | 5d | 2005-12-07 A | 2005-12-12 A | 21FS-2d | 100% | 2005-11-16 | 2005-11-22 | 6d |  | start no earlier than 2005-12-07 |
| 23 | 2.1.8 | Predelne stene |  | 19d | 2006-01-13 A | 2006-02-03 A |  | 100% | 2005-12-23 | 2006-02-10 | 36d |  | start no earlier than 2006-01-13 |
| 24 | 2.2 | **OBJEKT 2** |  | 107d | 2005-10-10 A | 2006-02-22 A |  | 100% | 2005-10-06 | 2006-02-15 | 105d |  |  |
| 25 | 2.2.1 | **TEMELJI** |  | 15d | 2005-10-10 A | 2005-10-26 A |  | 100% | 2005-10-06 | 2005-10-22 | 15d |  |  |
| 26 | 2.2.1.1 | Izkop za temelje |  | 1d | 2005-10-10 A | 2005-10-10 A |  | 100% | 2005-10-06 | 2005-10-08 | 3d |  | start no earlier than 2005-10-10 |
| 27 | 2.2.1.2 | Podložni beton pod temelji |  | 7d | 2005-10-11 A | 2005-10-18 A | 26FS-2d | 100% | 2005-10-07 | 2005-10-13 | 6d |  | start no earlier than 2005-10-11 |
| 28 | 2.2.1.3 | Izdelava temeljev točkovnih in pasovnih, zasip za temelji |  | 6d | 2005-10-20 A | 2005-10-26 A | 27SS+1d | 100% | 2005-10-08 | 2005-10-21 | 12d |  | start no earlier than 2005-10-20 |
| 29 | 2.2.1.4 | vgrajevanje tampona z utrjevanjem | milestone | 0d | 2005-10-24 A | 2005-10-24 A | 28SS+3d | 100% | 2005-10-12 | 2005-10-22 | 10d |  | finish no earlier than 2005-10-08 |
| 30 | 2.2.2 | KANALIZACIJA notranja, kinete, zasip |  | 6d | 2005-10-12 A | 2005-10-18 A | 29SS+1d | 100% | 2005-10-13 | 2005-10-24 | 10d |  | start no earlier than 2005-10-12 |
| 31 | 2.2.3 | TALNA PLOŠČA |  | 6d | 2005-10-20 A | 2005-10-26 A | 28SS+5d | 100% | 2005-10-14 | 2005-10-25 | 10d |  | start no earlier than 2005-10-17 |

| ID | WBS | Task | Duration | Start | Finish | Predecessors | Complete | Baseline start | Baseline finish | Baseline duration | Constraint |
| --- | --- | --- | --- | --- | --- | --- | --- | --- | --- | --- | --- |
| 32 | 2.2.4 | **PRITLIČJE** | 30d | 2005-11-15 A | 2005-12-19 A |  | 100% | 2005-10-26 | 2005-11-14 | 15d |  |
| 33 | 2.2.4.1 | ab stene, stebri, vertikalne vezi | 13d | 2005-12-02 A | 2005-12-16 A | 31 | 100% | 2005-10-26 | 2005-11-08 | 10d | start no earlier than 2005-12-02 |
| 34 | 2.2.4.2 | zidanje zidov | 20d | 2005-11-15 A | 2005-12-07 A | 33SS | 100% | 2005-10-26 | 2005-11-07 | 9d | start no earlier than 2005-11-12 |
| 35 | 2.2.4.3 | horizontalne vezi, preklade, pošča | 12d | 2005-12-06 A | 2005-12-19 A | 33FS-3d | 100% | 2005-11-05 | 2005-11-14 | 8d | start no earlier than 2005-12-01 |
| 36 | 2.2.5 | **1. ETAŽA** | 31d | 2005-12-14 A | 2006-01-27 A |  | 100% | 2005-11-11 | 2006-01-26 | 59d |  |
| 37 | 2.2.5.1 | ab stene, stebri, vertikalne vezi | 21d | 2005-12-17 A | 2006-01-19 A | 35FS-3d | 100% | 2005-11-11 | 2005-11-21 | 9d | finish no earlier than 2006-01-19 |
| 38 | 2.2.5.2 | zidanje zidov | 23d | 2005-12-14 A | 2006-01-18 A | 37SS | 100% | 2005-11-11 | 2005-11-21 | 9d | start no earlier than 2005-12-14 |
| 39 | 2.2.5.3 | horizontalne vezi, preklade, pošča | 26d | 2005-12-20 A | 2006-01-27 A | 37FS-2d | 100% | 2005-11-19 | 2006-01-26 | 8d | start no earlier than 2005-12-20 |
| 40 | 2.2.6 | VENEC NA STREHI | 4d | 2006-01-28 A | 2006-02-01 A | 39FS-2d | 100% | 2006-01-31 | 2006-02-06 | 6d | start no earlier than 2006-01-28 |
| 41 | 2.2.7 | Predelne stene | 15d | 2006-02-06 A | 2006-02-22 A |  | 100% | 2006-01-16 | 2006-02-15 | 27d | start no earlier than 2006-02-06 |
